Schedule from MS Project MPX, 2007-01-11 to 2007-01-11.

## Calendars

- Standard: Mon-Fri 08:00-12:00, 13:00-17:00; Sat-Sun off.

## Resources

| Resource |
| --- |
| Dudek |

## Schedule

| ID | WBS | Task |
| --- | --- | --- |
| 1 | 1 | **Bladder tests** |
| 2 | 1.1 | Define test plan. Set up test fixture. Order bladders, fill materials, and candidate epoxies for bladder tests. |
| 3 | 1.2 | Perform bench test of Teflon bladder to determine properties |
| 4 | 1.3 | Review structural analyses to determine bladder performance requirements. Verify adequate performance of Teflon bladder. |
| 5 | 1.4 | Develop procurement drawings for bladder |
| 6 | 1.5 | Conduct FDR of bladder design |
| 7 | 1.6 | Resolve FDR issues, release procurement drawings for fabrication |
| 8 | 1.7 | Procure bladders |
| 9 | 2 | **Coefficient of friction (COF) tests** |
| 10 | 2.1 | Order candidate materials for screening tests |
| 11 | 2.2 | Pick surface treatment for standard shims. Prepare shims for additional testing. |
| 12 | 2.3 | Perform additional COF tests (LN2 testing, cyclic tests, COF versus normal pressure, etc) for standard shims |
| 13 | 2.4 | Pick and order material for high COF shims |
| 14 | 2.5 | Perform additional COF tests (LN2 testing, cyclic tests, COF versus normal pressure, etc) for high COF shims |
| 15 | 2.6 | Document and conduct review of test results |
| 16 | 4 | **Tension tests of a bolted joint** |
| 17 | 4.1 | Develop drawings of prototypical bolted joint for tapped hole and through hole joints |
| 18 | 4.2 | Procure/fab parts for joint test |
| 19 | 4.3 | Pick candidate concepts for tightening nuts |
| 20 | 4.4 | Procure tools for tightening nuts |
| 21 | 4.5 | Develop design of test fixture and instrumentation |
| 22 | 4.6 | Set up test fixture and equipment |
| 23 | 4.7 | Measure joint deflection v. preload (include UT or SG measurement of bolt tension) |
| 24 | 4.8 | Measure joint deflection v. temperature (including candidate washer materials) |
| 25 | 4.9 | Measure joint relaxation v. time (days) |
| 26 | 4.10 | Measure joint relaxation v. cooldown cycles |
| 27 | 4.11 | Perform pullout tests for tapped holes |
| 28 | 4.12 | Document and conduct review of test results |
| 29 | 4.13 | Procure studs, nuts, and washers |
| 30 | 4.14 | Perform analyses to determine geometry and location of high COF shims and placement of new studs |
| 31 | 4.15 | Procure studs, nuts, and washers for new studs |

| ID | WBS | Task |
| --- | --- | --- |
| 32 | 5 | **Bushing tests** |
| 33 | 5.1 | Indentify candidate schemes for getting a bushing the fits tightly into the hole and around a stud |
| 34 | 5.2 | Procure bushing materials for tests. Fabricate bushings. |
| 35 | 5.3 | Procure tools and materials required for bushing assembly. |
| 36 | 5.4 | Perform trial bushing installations (short of gluing them in) on a production coil. |
| 37 | 5.5 | Document test results. Select bushing configuration. Conduct peer review of test results and bushing selection. |
| 38 | 5.6 | Procure bushing materials for assembly operations. |
| 39 | 6 | **Shear tests of a bolted joint** |
| 40 | 6.1 | Update bolted joint drawings with standard and high COF shims based on friction tests, bushing tests, and tension tests |
| 41 | 6.2 | Procure/fab parts for test |
| 42 | 6.3 | Set up test fixture |
| 43 | 6.4 | Measure joint deflection version shear load. Pull to failure. |
| 44 | 6.5 | Document and conduct peer review of test results |
| 45 | 6.6 | Procure/fab shims for assembly operations |
| 46 | 7 | **Complete design of MC interface hdw** |
| 47 | 7.1 | Establish design criteria for bolted joints |
| 48 | 7.2 | Perform analyses to determine geometry and location of high COF shims and placement of new bolts |
| 49 | 7.3 | Perform structural analyses to establish the adequacy of the proposed design |
| 50 | 7.4 | Develop specs and drawings |
| 51 | 7.5 | Conduct MC interface FDR |
| 52 | 7.6 | Resolve issues, release assembly spec and drawings |
| 53 | 8 | **Complete the design of the tooling and alignment mechanisms** |
| 54 | 8.1 | **Prepare Sta2 for initial operations** |
| 55 | 8.1.1 | Conduct JHA |
| 56 | 8.1.2 | Conduct ACC review of Sta2 |
| 57 | 8.1.3 | Resolve ACC findings |
| 58 | 8.1.4 | Receive RLM authorization for Sta2 initial ops |
| 59 | 8.2 | Perform trial x-y-z alignments on C1-C2. Demonstrate capability to satisfy alignment requirements. |
| 60 | 8.3 | Prototype bladder installation on C1-C2 |
| 61 | 8.4 | Establish alignment mechanisms, metrology equipment complement and positioning requirements, fiducial locations, etc. Conduct peer review. |
| 62 | 8.5 | Procure alignment mechanisms, fiducials, lifting equipment, etc. for assembly operations |

| ID | WBS | Task | Duration | Start | Finish | Baseline start | Baseline finish | Baseline duration |
| --- | --- | --- | --- | --- | --- | --- | --- | --- |
| 63 | 9 | **Finalize preparations for assembly operations** |  |  |  |  |  |  |
| 64 | 9.1 | Document dimensional control plan |  |  |  |  |  |  |
| 65 | 9.2 | Document assembly sequence |  |  |  |  |  |  |
| 66 | 9.3 | Finalize assembly procedure |  |  |  |  |  |  |
| 67 | 9.4 | Establish back office support requirements and data flow |  |  |  |  |  |  |
| 68 | 9.5 | Train technicians in operation of the metrology equipment and measurement procedures |  |  |  |  |  |  |
| 69 | 9.6 | Receive RLM authorization for assembly operations |  |  |  |  |  |  |
| 70 | 10 | **Finalize design of coil assemblies** | 1.00d | 2007-01-11 | 2007-01-11 | 2007-01-11 | 2007-01-11 | 1.00d |
| 71 | 10.1 | FInalize coolant tube supports and terminations |  |  |  |  |  |  |
| 72 | 10.2 | Finalize instrumenation design (TCs and strain gages) |  |  |  |  |  |  |
| 73 | 10.3 | Complete coil assembly spec and dwgs |  |  |  |  |  |  |
| 74 | 10.4 | Conduct FDR. Resolve issues. Release drawings. |  |  |  |  |  |  |
| 75 | 10.5 | Procure hardware required to finish coil assemblies |  |  |  |  |  |  |
| 76 | 12 | **Prepare coils for Sta2 operations** |  |  |  |  |  |  |
| 77 | 12.1 | Update installation procedures |  |  |  |  |  |  |
| 78 | 12.2 | Complete A1 coil |  |  |  |  |  |  |
| 79 | 12.3 | Complete A2 coil |  |  |  |  |  |  |
| 80 | 12.4 | Pre-fit A1-A2, resolve interferences |  |  |  |  |  |  |
| 81 | 12.5 | Complete B1 coil |  |  |  |  |  |  |
| 82 | 12.6 | Pre-fit A1-B1, resolve interferences |  |  |  |  |  |  |
| 83 | 12.7 | Complete C1 coil |  |  |  |  |  |  |
| 84 | 12.8 | Pre-fit B1-C1, resolve interferences |  |  |  |  |  |  |
| 85 | 13 | **Start Sta2 assembly operations** |  |  |  |  |  |  |
| 86 | 13.1 | Assemble/disassemble A1-A2 |  |  |  |  |  |  |
| 87 | 13.2 | Flip A1 |  |  |  |  |  |  |
| 88 | 13.3 | Assemble B1-A1 |  |  |  |  |  |  |
| 89 | 13.4 | Assemble C1-B1 |  |  |  |  |  |  |
| 90 | 13.5 | Remove HP1 (A1-B1-C1) |  |  |  |  |  |  |
