# ECP53_WTR_R4_mv

Schedule from MS Project, 2007-01-02 to 2007-05-22.

## Calendars

- Standard: Mon-Fri 08:00-12:00, 13:00-17:00; Sat-Sun off.

## Resources

| Resource |
| --- |
| Dudek |
| Fan |
| Williamson |
| Gettelfinger |
| Gettlefinger |
| Brooks |
| Viola |
| Brown |
| Freudenberg |
| DW |
| AB |
| KF |
| Cole |
| Ellis |

## Schedule

| ID | WBS | Task | Type | Duration | Start | Finish | Predecessors | Baseline start | Baseline finish | Baseline duration | Total slack | Free slack | Constraint | Resources | Work | Text1 |
| --- | --- | --- | --- | --- | --- | --- | --- | --- | --- | --- | --- | --- | --- | --- | --- | --- |
| 1 | 1 | **Bladder tests** |  | 88d | 2007-01-11 | 2007-05-14 |  | 2007-01-15 | 2007-05-14 | 86d | 6d |  |  |  | 528h |  |
| 2 | 1.1 | Define test plan. Set up test fixture. Order bladders, fill materials, and candidate epoxies for bladder tests. |  | 5d | 2007-01-15 | 2007-01-19 |  | 2007-01-15 | 2007-01-19 | 5d | 30d |  | start no earlier than 2007-01-15 | Dudek | 40h |  |
| 3 | 1.2 | Fill bladder. Perform bench test of Teflon bladder to determine properties. |  | 5d | 2007-03-05 | 2007-03-09 | 2, 18 | 2007-03-05 | 2007-03-09 | 5d | 0d |  | start no earlier than 2007-01-12 | Gettelfinger | 40h | After COF test are finished |
| 4 | 1.3 | Procure/fab prototype bladder for C-C installation |  | 15d | 2007-03-12 | 2007-03-30 | 5, 3 | 2007-03-12 | 2007-03-30 | 15d | 6d | 0d |  | Dudek | 120h |  |
| 5 | 1.4 | Review structural analyses to determine bladder performance requirements. Verify adequate performance of Teflon bladder. |  | 5d | 2007-01-22 | 2007-01-26 |  | 2007-01-22 | 2007-01-26 | 5d | 36d | 30d | start no earlier than 2007-01-22 | Fan | 40h |  |
| 6 | 1.5 | Determine if "one size fits all". Develop procurement drawings for bladder. |  | 10d | 2007-01-22 | 2007-02-02 |  | 2007-01-22 | 2007-02-02 | 10d | 51d | 45d | start no earlier than 2007-01-22 | Williamson | 80h |  |
| 7 | 1.6 | Conduct FDR of bladder design |  | 1d | 2007-04-09 | 2007-04-09 | 6, 87 | 2007-04-09 | 2007-04-09 | 1d | 6d | 0d |  | Williamson | 8h |  |
| 8 | 1.7 | Resolve FDR issues, release procurement drawings for fabrication |  | 5d | 2007-04-10 | 2007-04-16 | 7 | 2007-04-10 | 2007-04-16 | 5d | 6d | 0d |  | Williamson | 40h |  |
| 9 | 1.8 | Procure bladders for first FPA (2 ea) |  | 20d | 2007-04-17 | 2007-05-14 | 8 | 2007-04-17 | 2007-05-14 | 20d | 6d | 0d |  | Dudek | 160h |  |
| 10 | 1.9 | Bladders available for FPA | milestone | 0d | 2007-05-14 | 2007-05-14 | 9 | 2007-05-14 | 2007-05-14 | 0d | 6d | 1d |  |  |  |  |
| 12 | 2 | **Shims** |  | 94d | 2007-01-02 | 2007-05-11 |  | 2007-01-02 | 2007-05-11 | 94d | 0d |  |  |  | 520h |  |
| 13 | 2.1 | **Coefficient of friction (COF) tests** |  | 49d | 2007-01-02 | 2007-03-09 |  | 2007-01-02 | 2007-03-09 | 49d | 0d |  |  |  | 512h |  |
| 14 | 2.1.1 | Order candidate materials for screening tests. Perform screening tests. Pick shim surfaces. |  | 19d | 2007-01-02 | 2007-01-26 |  | 2007-01-02 | 2007-01-26 | 19d | 0d |  | start no earlier than 2007-01-02 | Gettelfinger | 152h |  |
| 15 | 2.1.2 | Prepare standard shims for additional testing. |  | 5d | 2007-01-29 | 2007-02-02 | 14 | 2007-01-29 | 2007-02-02 | 5d | 0d |  | start no earlier than 2007-01-02 | Gettelfinger | 40h |  |
| 16 | 2.1.3 | Perform additional COF tests (LN2 testing, cyclic tests, COF versus normal pressure, etc) for standard shims |  | 10d | 2007-02-05 | 2007-02-16 | 15 | 2007-02-05 | 2007-02-16 | 10d | 0d |  |  | Gettelfinger | 80h |  |
| 17 | 2.1.4 | Procure material for high COF shims. |  | 15d | 2007-01-29 | 2007-02-16 | 14 | 2007-01-29 | 2007-02-16 | 15d | 0d |  | start no earlier than 2007-01-02 | Gettlefinger | 120h |  |
| 18 | 2.1.5 | Perform additional COF tests (LN2 testing, cyclic tests, COF versus normal pressure, etc) for high COF shims |  | 10d | 2007-02-19 | 2007-03-02 | 17, 16 | 2007-02-19 | 2007-03-02 | 10d | 0d |  |  | Gettelfinger | 80h |  |
| 19 | 2.1.6 | Document and conduct peer review of test results |  | 5d | 2007-03-05 | 2007-03-09 | 18 | 2007-03-05 | 2007-03-09 | 5d | 2d | 0d |  | Gettlefinger | 40h |  |
| 20 | 2.1.7 | Shim surfaces defined | milestone | 0d | 2007-03-09 | 2007-03-09 | 19 | 2007-03-09 | 2007-03-09 | 0d | 2d | 0d |  |  |  |  |
| 21 | 2.2 | Define geometry of standard shim |  | 1d | 2007-01-19 | 2007-01-19 |  | 2007-01-19 | 2007-01-19 | 1d | 37d | 35d | start no earlier than 2007-01-19 | Williamson | 8h |  |
| 22 | 2.3 | Finalize procurement drawings. Conduct FDR |  | 5d | 2007-03-12 | 2007-03-16 | 20, 21 | 2007-03-12 | 2007-03-16 | 5d | 2d | 0d |  |  |  |  |
| 23 | 2.4 | Procure shims |  | 40d | 2007-03-19 | 2007-05-11 | 22 | 2007-03-19 | 2007-05-11 | 40d | 7d | 0d |  |  |  |  |
| 24 | 2.5 | Shims available for FPA | milestone | 0d | 2007-05-11 | 2007-05-11 | 23 | 2007-05-11 | 2007-05-11 | 0d | 7d | 2d |  |  |  |  |
| 26 | 4 | **Tension tests of a bolted joint** |  | 87d | 2007-01-11 | 2007-05-11 |  | 2007-01-22 | 2007-05-11 | 80d | 7d |  |  |  | 1376h |  |
| 27 | 4.1 | **Procure nuts, studs, and washers ASAP** |  | 80d | 2007-01-22 | 2007-05-11 |  | 2007-01-22 | 2007-05-11 | 80d | 7d |  |  |  | 680h |  |
| 28 | 4.1.1 | **Choose tools for tightening nuts** |  | 5d | 2007-01-22 | 2007-01-26 |  | 2007-01-22 | 2007-05-11 | 80d | 7d |  |  |  |  |  |
| 29 | 4.1.1 | Choose tools for tightening nuts |  | 5d | 2007-01-22 | 2007-01-26 |  | 2007-01-22 | 2007-01-26 | 5d | 7d | 0d | start no earlier than 2007-01-22 |  |  |  |

| ID | WBS | Task | Type | Duration | Start | Finish | Predecessors | Baseline start | Baseline finish | Baseline duration | Total slack | Free slack | Constraint | Resources | Work | Text1 |
| --- | --- | --- | --- | --- | --- | --- | --- | --- | --- | --- | --- | --- | --- | --- | --- | --- |
| 30 | 4.1.2 | **Perform analyses to determine geometry and location of high COF shims and placement of new studs. Characterize performance impacts of Low CTE washers.** |  | 10d | 2007-01-22 | 2007-02-02 |  | 2007-01-22 | 2007-05-11 | 80d | 12d |  |  |  | 80h |  |
| 31 | 4.1.2 | Perform analyses to determine geometry and location of high COF shims and placement of new studs. Characterize performance impacts of Low CTE washers. |  | 10d | 2007-01-22 | 2007-02-02 |  | 2007-01-22 | 2007-02-02 | 10d | 12d | 5d | start no earlier than 2007-01-22 | Brooks | 80h |  |
| 32 | 4.1.3 | Modify current drawing to accommodate hydraulic tensioners and UT inspection. Establish number for each length. |  | 5d | 2007-02-12 | 2007-02-16 | 29, 31, 75 | 2007-02-12 | 2007-02-16 | 5d | 7d | 0d | start no earlier than 2007-01-22 | Williamson | 40h | High priority |
| 33 | 4.1.4 | Develop cost and lead time estimates for nuts, studs, and washers of different materials. |  | 10d | 2007-01-22 | 2007-02-02 |  | 2007-01-22 | 2007-02-02 | 10d | 17d | 10d | start no earlier than 2007-01-22 | Williamson | 80h |  |
| 34 | 4.1.5 | Complete procurement drawings. Conduct peer review prior to long lead procurement. |  | 10d | 2007-02-19 | 2007-03-02 | 32, 33 | 2007-02-19 | 2007-03-02 | 10d | 7d | 0d |  | Williamson | 80h |  |
| 35 | 4.1.6 | Procure nuts studs and washers for start of FPA |  | 50d | 2007-03-05 | 2007-05-11 | 34 | 2007-03-05 | 2007-05-11 | 50d | 7d | 0d | start no earlier than 2007-01-22 | Williamson | 400h |  |
| 36 | 4.1.7 | Nuts, studs, and washers available for FPA | milestone | 0d | 2007-05-11 | 2007-05-11 | 35 | 2007-05-11 | 2007-05-11 | 0d | 7d |  |  |  |  |  |
| 37 | 4.2 | Develop drawings of prototypical bolted joint for tapped hole and through hole joints |  | 5d | 2007-02-19 | 2007-02-23 | 32 | 2007-02-19 | 2007-02-23 | 5d | 10d | 0d | start no earlier than 2007-01-22 | Williamson | 40h |  |
| 38 | 4.3 | Procure/fab parts for joint test. Use existing parts where possible |  | 15d | 2007-02-26 | 2007-03-16 | 37 | 2007-02-26 | 2007-03-16 | 15d | 47d |  |  | Dudek | 120h |  |
| 39 | 4.4 | Procure tools for tightening nuts |  | 15d | 2007-01-29 | 2007-02-16 | 29 | 2007-01-29 | 2007-02-16 | 15d | 20d | 5d |  | Dudek | 120h |  |
| 40 | 4.5 | Develop design of test fixture and instrumentation |  | 5d | 2007-03-12 | 2007-03-16 | 37, 3 | 2007-03-12 | 2007-03-16 | 5d | 0d |  | start no earlier than 2007-01-22 | Gettelfinger | 40h | After bladder tests are complete |
| 41 | 4.6 | Set up test fixture and equipment. Perform JHA and pre-job brief prior to proceeding. |  | 10d | 2007-03-19 | 2007-03-30 | 40, 39 | 2007-03-19 | 2007-03-30 | 10d | 0d |  |  | Gettelfinger | 80h |  |
| 42 | 4.7 | Measure joint deflection v. preload (include UT or SG measurement of bolt tension). Measure loss of preload after hydraulic pressure is removed. |  | 3d | 2007-04-02 | 2007-04-04 | 41 | 2007-04-02 | 2007-04-04 | 3d | 0d |  |  | Gettlefinger | 24h |  |
| 43 | 4.8 | Cool joint to 80K. Measure joint deflection and preload v. temperature (including candidate washer materials) |  | 3d | 2007-04-05 | 2007-04-09 | 42 | 2007-04-05 | 2007-04-09 | 3d | 0d |  |  | Gettelfinger | 24h |  |
| 44 | 4.9 | Measure joint deflection and preload v. time (days) at RT and 80K |  | 20d | 2007-04-02 | 2007-04-27 | 41 | 2007-04-02 | 2007-04-27 | 20d | 7d | 0d |  | Gettlefinger | 160h |  |
| 45 | 4.10 | Measure joint deflection and preload v. cooldown cycles |  | 3d | 2007-04-10 | 2007-04-12 | 43 | 2007-04-10 | 2007-04-12 | 3d | 0d |  |  | Gettlefinger | 24h |  |
| 46 | 4.11 | Perform pullout tests for tapped holes |  | 3d | 2007-04-13 | 2007-04-17 | 45 | 2007-04-13 | 2007-04-17 | 3d | 0d |  |  | Gettlefinger | 24h |  |
| 47 | 4.12 | Document and conduct review of test results |  | 5d | 2007-04-30 | 2007-05-04 | 46, 44 | 2007-04-30 | 2007-05-04 | 5d | 7d |  |  | Gettelfinger | 40h |  |
| 49 | 5 | **Bushing tests** |  | 72d | 2007-01-11 | 2007-04-20 |  | 2007-01-22 | 2007-04-20 | 65d | 14d |  |  |  | 640h |  |
| 50 | 5.1 | Indentify candidate schemes for getting a bushing the fits tightly into the hole and around a stud. Prepare sketches. |  | 5d | 2007-01-22 | 2007-01-26 |  | 2007-01-22 | 2007-01-26 | 5d | 7d | 0d | start no earlier than 2007-01-22 | Williamson | 40h |  |
| 51 | 5.2 | Procure bushing materials for tests. Fabricate bushings. |  | 15d | 2007-01-29 | 2007-02-16 | 50 | 2007-01-29 | 2007-02-16 | 15d | 7d | 0d | start no earlier than 2007-01-22 | Dudek | 120h |  |
| 52 | 5.3 | Procure tools and materials required for bushing assembly. |  | 15d | 2007-01-29 | 2007-02-16 | 50 | 2007-01-29 | 2007-02-16 | 15d | 7d | 0d |  | Dudek | 120h |  |
| 53 | 5.4 | Perform trial bushing installations (short of gluing them in) on a production coil. |  | 10d | 2007-02-19 | 2007-03-02 | 52, 51 | 2007-02-19 | 2007-03-02 | 10d | 7d | 0d |  | Viola | 80h |  |
| 54 | 5.5 | Document test results. Select bushing configuration. Conduct peer review of test results and bushing selection. |  | 5d | 2007-03-05 | 2007-03-09 | 53 | 2007-03-05 | 2007-03-09 | 5d | 7d | 0d |  | Viola | 40h |  |
| 55 | 5.6 | Procure bushing materials for assembly operations. Fabricate bushings. |  | 30d | 2007-03-12 | 2007-04-20 | 54 | 2007-03-12 | 2007-04-20 | 30d | 22d | 0d |  | Dudek | 240h |  |
| 56 | 5.7 | Bushings available for FPA operations | milestone | 0d | 2007-04-20 | 2007-04-20 | 55 | 2007-04-20 | 2007-04-20 | 0d | 22d | 17d |  |  |  |  |

| ID | WBS | Task | Type | Duration | Start | Finish | Predecessors | Baseline start | Baseline finish | Baseline duration | Total slack | Free slack | Constraint | Resources | Work |
| --- | --- | --- | --- | --- | --- | --- | --- | --- | --- | --- | --- | --- | --- | --- | --- |
| 58 | 6 | **Shear tests of a bolted joint** |  | 89d | 2007-01-11 | 2007-05-15 |  | 2007-03-19 | 2007-05-15 | 42d | 5d |  |  |  | 320h |
| 59 | 6.1 | Procure/fab parts for test and initial assembly |  | 20d | 2007-03-19 | 2007-04-13 | 22, 34, 54 | 2007-03-19 | 2007-04-13 | 20d | 2d |  |  | Dudek | 160h |
| 60 | 6.2 | Set up test fixture |  | 10d | 2007-04-18 | 2007-05-01 | 59, 46 | 2007-04-18 | 2007-05-01 | 10d | 0d |  |  | Gettlefinger | 80h |
| 61 | 6.3 | Measure joint deflection version shear load. Pull to failure. |  | 5d | 2007-05-02 | 2007-05-08 | 60 | 2007-05-02 | 2007-05-08 | 5d | 0d |  |  | Gettelfinger | 40h |
| 62 | 6.4 | Document test results |  | 5d | 2007-05-09 | 2007-05-15 | 61 | 2007-05-09 | 2007-05-15 | 5d | 0d |  |  | Gettelfinger | 40h |
| 64 | 7 | **Complete design of MC interface hdw** |  | 94d | 2007-01-11 | 2007-05-22 |  | 2007-01-22 | 2007-05-22 | 87d | 0d |  |  |  | 488h |
| 65 | 7.1 | Establish design criteria for bolted joints |  | 5d | 2007-01-22 | 2007-01-26 |  | 2007-01-22 | 2007-01-26 | 5d | 82d |  | start no earlier than 2007-01-22 | Fan | 40h |
| 66 | 7.2 | Perform analyses to determine geometry and location of high COF shims and placement of new bolts |  | 10d | 2007-01-22 | 2007-02-02 |  | 2007-01-22 | 2007-02-02 | 10d | 76d | 0d | start no earlier than 2007-01-22 | Brooks | 80h |
| 67 | 7.3 | Perform structural analyses to performance requirements for bolted joints |  | 10d | 2007-01-22 | 2007-02-02 |  | 2007-01-22 | 2007-02-02 | 10d | 76d | 0d | start no earlier than 2007-01-22 | AB; KF | 160h |
| 68 | 7.4 | Define reference bolted joint design |  | 5d | 2007-01-22 | 2007-01-26 |  | 2007-01-22 | 2007-01-26 | 5d | 81d | 5d | start no earlier than 2007-01-22 | Williamson | 40h |
| 69 | 7.5 | Conduct PDR to review requirements, design, and development plan |  | 1d | 2007-02-05 | 2007-02-05 | 14, 66, 67, 68 | 2007-02-05 | 2007-02-05 | 1d | 76d |  |  | Williamson | 8h |
| 70 | 7.6 | Develop specs and drawings for Station 2 and 3 assemblies |  | 15d | 2007-03-19 | 2007-04-06 | 22, 34, 54 | 2007-03-19 | 2007-04-06 | 15d | 27d |  |  | Cole | 120h |
| 71 | 7.7 | Conduct MC interface FDR | milestone | 0d | 2007-05-15 | 2007-05-15 | 70, 62, 47 | 2007-05-15 | 2007-05-15 | 0d | 0d |  |  | Williamson |  |
| 72 | 7.8 | Resolve issues, release assembly spec and drawings |  | 5d | 2007-05-16 | 2007-05-22 | 71 | 2007-05-16 | 2007-05-22 | 5d | 0d |  |  | Williamson | 40h |
| 74 | 8 | **Perform assembly trials. Procure tools and tooling.** |  | 77d | 2007-01-11 | 2007-04-27 |  | 2007-01-22 | 2007-04-27 | 70d | 17d |  |  |  | 1120h |
| 75 | 8.1 | Survey each coil type using templates. Determine stud length constraints based on access limitations for torquing/tensioning. |  | 10d | 2007-01-29 | 2007-02-09 | 29 | 2007-01-29 | 2007-02-09 | 10d | 7d | 0d |  | Viola | 80h |
| 76 | 8.2 | **Identify areas that need to be measured in post-VPI and ground** |  | 20d | 2007-01-22 | 2007-02-16 |  | 2007-01-22 | 2007-02-16 | 20d | 17d |  |  |  | 200h |
| 77 | 8.2.1 | Identify "close points" when assembling |  | 5d | 2007-01-22 | 2007-01-26 |  | 2007-01-22 | 2007-01-26 | 5d | 77d | 10d | start no earlier than 2007-01-22 | Brown | 40h |
| 78 | 8.2.2 | Perform fits of C-C, C-B, B-A, and A-A |  | 15d | 2007-01-22 | 2007-02-09 |  | 2007-01-22 | 2007-02-09 | 15d | 17d | 0d | start no earlier than 2007-01-22 | Viola | 120h |
| 79 | 8.2.3 | Provide guidance to revise post-VPI procedure to include measurement points |  | 5d | 2007-02-12 | 2007-02-16 | 77, 78 | 2007-02-12 | 2007-02-16 | 5d | 67d |  |  | Brown | 40h |
| 80 | 8.3 | Perform trial x-y-z alignments on C1-C2. Demonstrate capability to satisfy alignment requirements with individual shims of uniform thickness. |  | 10d | 2007-02-12 | 2007-02-23 | 78 | 2007-02-12 | 2007-02-23 | 10d | 17d | 0d |  | Viola | 80h |
| 81 | 8.4 | Establish alignment mechanisms, metrology equipment complement and positioning requirements, etc. Conduct peer review. |  | 5d | 2007-02-26 | 2007-03-02 | 80 | 2007-02-26 | 2007-03-02 | 5d | 17d | 0d |  | Viola | 40h |
| 82 | 8.5 | Procure alignment mechanisms, fiducials, lifting equipment, etc. for assembly operations |  | 40d | 2007-03-05 | 2007-04-27 | 81 | 2007-03-05 | 2007-04-27 | 40d | 17d | 0d |  | Dudek | 320h |
| 83 | 8.6 | Develop procedures for torquing bolts |  | 5d | 2007-02-26 | 2007-03-02 | 80, 39 | 2007-02-26 | 2007-03-02 | 5d | 17d | 0d |  | Viola | 40h |
| 84 | 8.7 | Determine fiducial types and locations |  | 10d | 2007-03-05 | 2007-03-16 | 83 | 2007-03-05 | 2007-03-16 | 10d | 17d | 0d |  | Viola | 80h |
| 85 | 8.8 | Procure monuments and related metrology equipment |  | 30d | 2007-03-19 | 2007-04-27 | 84 | 2007-03-19 | 2007-04-27 | 30d | 17d | 0d |  | Dudek | 240h |
| 86 | 8.9 | Tools and tooling available for FPA operations | milestone | 0d | 2007-04-27 | 2007-04-27 | 39, 82, 85 | 2007-04-27 | 2007-04-27 | 0d | 17d | 12d |  |  |  |
| 87 | 8.10 | Prototype bladder installation. |  | 5d | 2007-04-02 | 2007-04-06 | 4 | 2007-04-02 | 2007-04-06 | 5d | 6d | 0d |  | Viola | 40h |

| ID | WBS | Task | Type | Duration | Start | Finish | Predecessors | Baseline start | Baseline finish | Baseline duration | Total slack | Free slack | Resources | Work |
| --- | --- | --- | --- | --- | --- | --- | --- | --- | --- | --- | --- | --- | --- | --- |
| 89 | 9 | **Finalize preparations for assembly operations** |  | 89d | 2007-01-11 | 2007-05-15 |  | 2007-04-18 | 2007-05-15 | 20d | 5d |  |  | 200h |
| 90 | 9.1 | Document assembly sequence |  | 5d | 2007-04-18 | 2007-04-24 | 7, 22, 46, 54 | 2007-04-18 | 2007-04-24 | 5d | 5d | 0d | Ellis | 40h |
| 91 | 9.2 | Finalize dimensional control plan |  | 5d | 2007-04-25 | 2007-05-01 | 90 | 2007-04-25 | 2007-05-01 | 5d | 5d | 0d | Brown | 40h |
| 92 | 9.3 | Finalize assembly procedure |  | 5d | 2007-05-02 | 2007-05-08 | 91 | 2007-05-02 | 2007-05-08 | 5d | 5d | 0d | Viola | 40h |
| 93 | 9.4 | Establish back office support requirements and data flow |  | 5d | 2007-05-09 | 2007-05-15 | 92 | 2007-05-09 | 2007-05-15 | 5d | 5d | 0d | Viola | 40h |
| 94 | 9.5 | Train technicians in operation of the metrology equipment and measurement procedures |  | 5d | 2007-05-09 | 2007-05-15 | 92 | 2007-05-09 | 2007-05-15 | 5d | 5d | 0d | Viola | 40h |
| 95 | 9.6 | RLM authorization for assembly operations | milestone | 0d | 2007-05-15 | 2007-05-15 | 93, 94 | 2007-05-15 | 2007-05-15 | 0d | 5d | 0d | Dudek |  |
| 97 | 10 | Start Station 2 assembly operations | milestone | 0d | 2007-05-15 | 2007-05-15 | 10, 24, 56, 71, 86, 95 | 2007-05-15 | 2007-05-15 | 0d | 5d |  | Viola |  |
